# 2017 Winter Shut Down Target Hall Schedule

Schedule from MS Project, 2016-11-23 to 2017-04-05, A marks actual dates.

## Calendars

- Standard: Mon-Fri 08:00-12:00, 13:00-17:00; Sat-Sun off.

## Resources

| Resource |
| --- |
| Anders Mjos |
| David Wang |
| Yasmine Saboui |
| Tavis Cave |
| Chad Fisher |
| Aurelia Laxdal |
| Vacuum Group |
| Grant Minor |
| Rob Walker |

## Schedule

| ID | Task | Duration | Start | Finish | Predecessors | Complete | Total slack | Free slack | Constraint | Resources | Work | Actual work |
| --- | --- | --- | --- | --- | --- | --- | --- | --- | --- | --- | --- | --- |
| 1 | Shielding Blocks Move- ITW to Storage Area | 1d | 2017-01-03 A | 2017-01-03 A |  | 100% |  |  | start no earlier than 2017-01-03 | David Wang | 8h | 8h |
| 2 | Anchor Bolts Clean out- Silo area | 1d | 2017-01-04 A | 2017-01-04 A |  | 100% |  |  | finish no earlier than 2017-01-04 | David Wang | 8h | 8h |
| 3 | Silos Re-arrangement | 2d | 2017-01-05 A | 2017-01-06 A | 2 | 100% |  |  | finish no earlier than 2017-01-06 | David Wang; Yasmine Saboui | 32h | 32h |
| 4 | Module Disconnection TM2- ITW( Except vacuum) | 1d | 2017-01-09 A | 2017-01-09 A | 3 | 100% |  |  | start no earlier than 2017-01-09 | David Wang | 8h | 8h |
| 5 | ITW and TM2 Shutdown Leak Check | 4d | 2017-01-10 A | 2017-01-13 A | 4 | 100% |  |  | finish no earlier than 2017-01-13 |  |  |  |
| 6 | Module Disconnection TM4-ITE(Except Vacuum) | 1d | 2017-01-16 A | 2017-01-16 A | 5 | 100% |  |  | start no earlier than 2017-01-16 |  |  |  |
| 7 | ITE and TM4 Shut Down Leak Check | 2d | 2017-01-17 A | 2017-01-18 A | 6 | 100% |  |  | finish no earlier than 2017-01-11 | David Wang | 16h | 16h |
| 8 | Module Move-TM2- ITW to SHC | 1d | 2017-01-23 | 2017-01-23 | 7 |  | 50.5d | 0d | finish no earlier than 2017-01-23 | Yasmine Saboui; David Wang | 16h |  |
| 9 | Febiad Target Installation | 1d | 2017-01-24 | 2017-01-24 | 8 |  | 50.5d | 1d | finish no earlier than 2017-01-24 | Chad Fisher | 8h |  |
| 10 | ITW TP4 Replacement | 1d | 2016-11-23 | 2016-11-23 |  |  | 95d |  | start no earlier than 2016-11-23 |  |  |  |
| 11 | Module Move-TM2 - SHC to ITW | 0.5d | 2017-01-26 | 2017-01-26 | 9 |  | 49.5d |  | start no earlier than 2017-01-26 | Yasmine Saboui; David Wang | 8h |  |
| 12 | Module Connection-TM2 -ITW/ Start of Pumps | 0.5d | 2017-01-26 | 2017-01-26 |  |  | 44d | 0d | finish no earlier than 2017-01-26 | David Wang; Yasmine Saboui | 8h |  |
| 13 | Spent Target UCX Move- SHC to Storage Vault | 1d | 2017-01-27 | 2017-01-27 | 12 |  | 44d | 16d | start no earlier than 2017-01-27 | Yasmine Saboui; Chad Fisher | 16h |  |
| 14 | Target Hall Crane Inspection | 3d | 2017-02-06 | 2017-02-08 |  |  | 40d |  | start no earlier than 2017-02-06 |  |  |  |
| 15 | Module Disconnection TM4- ITE( vacuum) | 0.5d | 2017-02-21 | 2017-02-21 | 13 |  | 28d | 0d | start no earlier than 2017-02-21 | David Wang | 4h |  |
| 16 | Module Move-TM4-ITE to SHC | 0.5d | 2017-02-21 | 2017-02-21 | 15 |  | 28d | 0d | start no earlier than 2017-02-02 | Yasmine Saboui; David Wang | 8h |  |
| 17 | Old Target Removal/ TM4 Basic Electrical Check) | 1d | 2017-02-22 | 2017-02-22 | 16 |  | 28d | 0d | start no earlier than 2017-02-02 | David Wang; Chad Fisher | 16h |  |
| 18 | Module Move- TM4- SHC to Silo | 1d | 2017-02-23 | 2017-02-23 | 17 |  | 28d | 0d | start no earlier than 2017-02-03 | Yasmine Saboui; David Wang | 16h |  |
| 19 | Spent Target Move- SHC to Storage Vault | 1d | 2017-02-24 | 2017-02-24 | 18 |  | 28d |  | start no earlier than 2017-02-06 | Chad Fisher; Yasmine Saboui; David Wang | 24h |  |
| 20 | Module Disconnection- TM2- ITW | 0.25d | 2017-03-01 | 2017-03-01 |  |  | 0d |  | start no earlier than 2017-03-01 | David Wang | 2h |  |
| 21 | Module Move-TM2 to Silo | 0.75d | 2017-03-01 | 2017-03-01 | 20 |  | 0d |  | start no earlier than 2017-03-01 | Tavis Cave; Yasmine Saboui | 12h |  |
| 22 | ISAC High Active Water Resin Can Replacement | 4d | 2017-03-02 | 2017-03-07 | 21 |  | 0d |  | start no earlier than 2017-03-02 | David Wang; Yasmine Saboui | 64h |  |
| 23 | ITW 2" Return Line Ball Valve Repairing | 1d | 2017-03-08 | 2017-03-08 | 22 |  | 0d |  | start no earlier than 2017-03-08 | David Wang | 8h |  |
| 24 | Vacuum gauge Installlation on Turbo Back Line for ISAC Target Station | 5d | 2017-03-02 | 2017-03-08 | 21 |  | 20d |  | start no earlier than 2017-03-02 | Vacuum Group | 40h |  |
| 25 | Clean ITW and ITE | 2d | 2017-03-09 | 2017-03-10 | 23 |  | 0d |  | start no earlier than 2017-03-09 | David Wang | 16h |  |
| 26 | ISAC Target Pit Module Move Ventilation | 18d | 2017-03-13 | 2017-04-05 | 25 |  | 0d |  | start no earlier than 2017-03-13 | Anders Mjos; Rob Walker; Vacuum Group | 432h |  |
